# EVS Qualification,r4

Schedule from MS Project, 2012-01-02 to 2012-11-09.
Ericsson AB

## Calendars

- Standard: Mon-Fri 08:00-12:00, 13:00-17:00; Sat-Sun off.

## Schedule

| ID | WBS | Task | Type | Duration | Start | Finish | Predecessors | Total slack | Free slack | Constraint |
| --- | --- | --- | --- | --- | --- | --- | --- | --- | --- | --- |
| 1 | 1 | **EVS PD finalization** |  | 160d | 2012-01-02 | 2012-08-10 |  | 0d |  |  |
| 2 | 1.1 | Blinding Procedures |  | 5d | 2012-04-16 | 2012-04-20 | 3FF | 15d | 0d |  |
| 3 | 1.2 | Qualification deliverables EVS-6a | manual | 80d | 2012-01-02 | 2012-04-20 | 51FF |  |  | start no earlier than 2012-01-01 |
| 4 | 1.3 | Performance requirements EVS-3 with priorities for qualification | manual | 105d | 2012-01-02 | 2012-05-25 | 52FF |  |  | as late as possible |
| 5 | 1.4 | Remaining performance requirements |  | 55d | 2012-05-28 | 2012-08-10 | 4 | 65d | 5d |  |
| 6 | 1.5 | Qualification rules EVS-5a incl. Selection Metric | manual | 105d | 2012-01-02 | 2012-05-25 | 52FF, 4FF |  |  | start no earlier than 2012-01-02 |
| 7 | 1.6 | Test Plan EVS-8a | manual | 105d | 2012-01-02 | 2012-05-25 | 52FF, 4FF |  |  |  |
| 8 | 1.7 | Processing Plan EVS-7a | manual | 105d | 2012-01-02 | 2012-05-25 | 4FF, 52FF |  |  |  |
| 9 | 2 | **Processing preparations** |  | 40d | 2012-05-14 | 2012-07-09 |  | 0d |  |  |
| 10 | 2.1 | Develop Processing Scripts |  | 15d | 2012-05-14 | 2012-06-01 | 8FF+5d | 0d |  |  |
| 11 | 2.2 | Cross-Checking of Processing Scripts with tentative material and CuTs |  | 10d | 2012-05-28 | 2012-06-08 | 10FS-5d | 0d |  |  |
| 12 | 2.3 | (Optional) pre-XC with preliminary CuTs from PCs to identify potential problems |  | 20d | 2012-06-11 | 2012-07-06 | 11 | 0d |  | as late as possible |
| 13 | 2.4 | Speech Source Material to HL |  | 5d | 2012-06-04 | 2012-06-08 | 7, 8, 19, 20 | 20d |  |  |
| 14 | 2.5 | Noise Source Material to HL |  | 5d | 2012-06-04 | 2012-06-08 | 7, 8, 19, 20 | 20d |  |  |
| 15 | 2.6 | Mixed and music material collection |  | 10d | 2012-06-04 | 2012-06-15 | 7, 8, 19, 20 | 5d | 0d |  |
| 16 | 2.7 | Mixed and music signal selection |  | 10d | 2012-06-18 | 2012-06-29 | 15 | 5d |  |  |
| 17 | 2.8 | CuT Executable submission | milestone | 0d | 2012-07-09 | 2012-07-09 | 19 | 0d |  | as late as possible |
| 18 | 3 | **contractual preparations** |  | 30d | 2012-04-23 | 2012-06-01 |  | 5d |  |  |
| 19 | 3.1 | NDAs finalized |  | 15d | 2012-04-23 | 2012-05-11 | 2 | 15d | 10d |  |
| 20 | 3.2 | Contracts finalized |  | 5d | 2012-05-28 | 2012-06-01 | 7, 8, 19, 21 | 5d | 0d |  |
| 21 | 3.3 | Funds available at ETSI | milestone, manual | 0d | 2012-05-28 | 2012-05-28 |  |  |  |  |
| 22 | 4 | **Infrastructrural preparations** |  | 5d | 2012-06-04 | 2012-06-08 |  | 23d |  |  |
| 23 | 4.1 | FTP site setup and testing |  | 1d | 2012-06-04 | 2012-06-04 | 20 | 23d | 0d |  |
| 24 | 4.2 | Definition of a secure data transmission process |  | 5d | 2012-06-04 | 2012-06-08 | 20 | 110d |  |  |
| 25 | 4.3 | HL creates XC folders |  | 1d | 2012-06-05 | 2012-06-05 | 20, 23 | 23d | 0d |  |
| 26 | 4.4 | BL creates Response and Blind folders |  | 1d | 2012-06-06 | 2012-06-06 | 25 | 112d |  |  |
| 27 | 4.5 | Definition of a Subjective Test Data Transfer Form |  | 5d | 2012-06-04 | 2012-06-08 | 20 | 45d | 30d |  |

| ID | WBS | Task | Type | Duration | Start | Finish | Predecessors | Total slack | Free slack | Deadline |
| --- | --- | --- | --- | --- | --- | --- | --- | --- | --- | --- |
| 28 | 5 | **NB phase** |  | 60d | 2012-07-09 | 2012-09-28 |  | 0d |  |  |
| 29 | 5.1 | XC-NB |  | 10d | 2012-07-09 | 2012-07-20 | 11, 13, 14, 17, 25, 16, 12 | 0d |  |  |
| 30 | 5.2 | HL Delivers NB tests |  | 5d | 2012-07-16 | 2012-07-20 | 29FF | 15d | 0d |  |
| 31 | 5.3 | NB testing |  | 40d | 2012-07-23 | 2012-09-14 | 30, 27 | 15d | 0d |  |
| 32 | 5.4 | BL delivers NB test results to GAL |  | 5d | 2012-09-10 | 2012-09-14 | 31FF | 15d | 0d |  |
| 33 | 5.5 | GAL NB |  | 10d | 2012-09-17 | 2012-09-28 | 32 | 15d |  |  |
| 34 | 6 | **WB phase** |  | 60d | 2012-07-23 | 2012-10-12 |  | 0d |  |  |
| 35 | 6.1 | XC-WB |  | 10d | 2012-07-23 | 2012-08-03 | 11, 13, 14, 17, 25, 29, 16 | 0d |  |  |
| 36 | 6.2 | HL Delivers WB tests |  | 5d | 2012-07-30 | 2012-08-03 | 35FF | 5d | 0d |  |
| 37 | 6.3 | WB testing |  | 40d | 2012-08-06 | 2012-09-28 | 36, 27 | 5d | 0d |  |
| 38 | 6.4 | BL delivers WB test results to GAL |  | 5d | 2012-09-24 | 2012-09-28 | 37FF | 5d | 0d |  |
| 39 | 6.5 | GAL WB |  | 10d | 2012-10-01 | 2012-10-12 | 38 | 5d |  |  |
| 40 | 7 | **SWB phase** |  | 55d | 2012-08-06 | 2012-10-19 |  | 0d |  |  |
| 41 | 7.1 | XC-SWB |  | 10d | 2012-08-06 | 2012-08-17 | 11, 13, 14, 17, 25, 35, 16 | 0d |  |  |
| 42 | 7.2 | HL Delivers SWB tests |  | 5d | 2012-08-13 | 2012-08-17 | 41FF | 0d |  |  |
| 43 | 7.3 | SWB testing |  | 40d | 2012-08-20 | 2012-10-12 | 42, 27 | 0d |  |  |
| 44 | 7.4 | BL delivers SWB test results to GAL |  | 5d | 2012-10-08 | 2012-10-12 | 43FF | 0d |  |  |
| 45 | 7.5 | GAL SWB |  | 10d | 2012-10-08 | 2012-10-19 | 44FS-5d | 0d |  |  |
| 46 | 8 | **Final reporting phase** |  | 55d | 2012-08-20 | 2012-11-02 |  | 0d |  |  |
| 47 | 8.1 | Global Analysis Final Report |  | 7d | 2012-10-22 | 2012-10-30 | 33, 39, 45 | 0d |  | 2012-10-30 |
| 48 | 8.2 | Cross-Check of the Global Analysis |  | 3d | 2012-10-31 | 2012-11-02 | 47 | 0d |  |  |
| 49 | 8.3 | HL Final Report |  | 5d | 2012-08-20 | 2012-08-24 | 42 | 47d | 46d | 2012-10-30 |
| 50 | 8.4 | Qualification deliverables incl. LL reports |  | 10d | 2012-10-15 | 2012-10-26 | 31, 37, 43 | 2d | 1d | 2012-10-30 |
| 51 | 9 | SA4#68 Kyoto | manual | 6d | 2012-04-13 | 2012-04-20 |  |  |  |  |
| 52 | 10 | SA4#69 Erlangen | manual | 6d | 2012-05-19 | 2012-05-25 |  |  |  |  |
| 53 | 11 | SA4#70 Chicago | manual | 5d | 2012-08-13 | 2012-08-17 | 5FF |  |  |  |
| 54 | 12 | SA4#71 Document submission deadline | milestone, manual | 0d | 2012-10-30 | 2012-10-30 | 50, 49, 47 |  |  |  |
| 55 | 13 | SA4#71 Bratislava | manual | 5d | 2012-11-05 | 2012-11-09 | 48, 54 |  |  |  |
